# MoveOfficeExporting

How a schedule from MS Project changed from version to version. A marks actual dates.

## Version 1 (data date 2010-01-28, saved 2010-09-20, file MoveOfficeExporting.mpp)

| ID | WBS | Task | Duration | Start | Finish | Predecessors | Complete | Total float | Constraint |
| --- | --- | --- | --- | --- | --- | --- | --- | --- | --- |
| 1 | 1 | **Progress Meeting** | 20.12d | 2010-01-04 08:00 A | 2010-02-01 09:00 |  | 80% | 0d |  |
| 2 |  | Progress Meeting 1 | 1h | 2010-01-04 08:00 A | 2010-01-04 09:00 A |  | 100% |  | start no earlier than 2010-01-04 08:00 |
| 3 |  | Progress Meeting 2 | 1h | 2010-01-11 08:00 A | 2010-01-11 09:00 A |  | 100% |  | start no earlier than 2010-01-11 08:00 |
| 4 |  | Progress Meeting 3 | 1h | 2010-01-18 08:00 A | 2010-01-18 09:00 A |  | 100% |  | start no earlier than 2010-01-18 08:00 |
| 5 |  | Progress Meeting 4 | 1h | 2010-01-25 08:00 A | 2010-01-25 09:00 A |  | 100% |  | start no earlier than 2010-01-25 08:00 |
| 6 |  | Progress Meeting 5 | 1h | 2010-02-01 08:00 | 2010-02-01 09:00 |  |  |  | start no earlier than 2010-02-01 08:00 |
| 7 | 2 | **Pre-work** | 5.25d | 2010-01-04 08:00 A | 2010-01-11 10:00 A |  | 100% |  |  |
| 8 |  | Get Fit-out quotes | 2d | 2010-01-04 08:00 A | 2010-01-05 17:00 A |  | 100% |  |  |
| 9 |  | Get Moving Company Quotes | 1d | 2010-01-06 08:00 A | 2010-01-06 17:00 A | 8 | 100% |  |  |
| 10 |  | Evaluate and Accept Quotes | 5h | 2010-01-07 08:00 A | 2010-01-07 14:00 A | 9 | 100% |  |  |
| 11 |  | Confirm Moving Day | 2h | 2010-01-11 08:00 A | 2010-01-11 10:00 A | 10 | 100% |  | finish no later than 2010-01-08 17:00 |
| 12 | 3 | **Fit Out New Premises** | 7.5d | 2010-01-11 10:00 A | 2010-01-20 15:00 A | 7 | 100% |  |  |
| 13 |  | Power | 0.5d | 2010-01-11 10:00 A | 2010-01-11 15:00 A |  | 100% |  |  |
| 14 |  | Cabling | 4d | 2010-01-11 15:00 A | 2010-01-15 15:00 A | 13 | 100% |  |  |
| 15 |  | Decorating | 1w | 2010-01-13 15:00 A | 2010-01-20 15:00 A | 14FS-5% | 100% |  |  |
| 16 | 4 | **Packing** | 6d | 2010-01-20 15:00 A | 2010-01-28 15:00 A | 12 | 100% |  |  |
| 17 |  | Get Boxes | 1d | 2010-01-20 15:00 A | 2010-01-21 15:00 A |  | 100% |  |  |
| 18 |  | Pack boxes | 1w | 2010-01-21 15:00 A | 2010-01-28 15:00 A | 17 | 100% |  |  |
| 19 |  | Make Inventory | 1w | 2010-01-21 15:00 A | 2010-01-28 15:00 A | 18SS | 100% |  |  |
| 20 |  | Transport Boxes | 1ed | 2010-01-28 15:00 A | 2010-01-29 15:00 | 16 | 8% | 0d |  |
| 21 | 6 | **Unpacking** | 5d | 2010-01-29 15:00 | 2010-02-05 15:00 | 20 |  | 0d |  |
| 22 |  | Unpack Boxes | 1w | 2010-01-29 15:00 | 2010-02-05 15:00 |  |  | 0d |  |
| 23 |  | Install Equipment | 1w | 2010-01-29 15:00 | 2010-02-05 15:00 | 22FF |  | 0d |  |
| 24 |  | Check Inventory | 1w | 2010-01-29 15:00 | 2010-02-05 15:00 | 23FF |  | 0d |  |
| 25 |  | Move In | 0d | 2010-02-05 15:00 | 2010-02-05 15:00 | 21 |  | 0d |  |

## Version 2 (data date 2010-01-28, saved 2010-09-22, file SharedProject1Practice.mpp)

Last finish 2010-02-05 → 2010-02-04 (-1d). Complete tasks 14 → 0.

Removed: 1 Progress Meeting; 2 Progress Meeting 1; 3 Progress Meeting 2; 4 Progress Meeting 3; 5 Progress Meeting 4; 6 Progress Meeting 5

Changed:

| ID | Task | Start | Finish | Duration | Complete | Total float | Other |
| --- | --- | --- | --- | --- | --- | --- | --- |
| 1 | **Pre-work** | 2010-01-04 08:00 A → 2010-01-04 | 2010-01-11 10:00 A → 2010-01-07 (-4d) | 5.25d → 3.62d | 100% → 0% | none → 0d | baseline start 2010-01-04 08:00 → none; baseline finish 2010-01-07 14:00 → none |
| 2 | Get Fit-out quotes | 2010-01-04 08:00 A → 2010-01-04 | 2010-01-05 17:00 A → 2010-01-05 |  | 100% → 0% | none → 0d | baseline start 2010-01-04 08:00 → none; baseline finish 2010-01-05 17:00 → none |
| 3 | Get Moving Company Quotes | 2010-01-06 08:00 A → 2010-01-06 | 2010-01-06 17:00 A → 2010-01-06 |  | 100% → 0% | none → 0d | baseline start 2010-01-06 08:00 → none; baseline finish 2010-01-06 17:00 → none |
| 4 | Evaluate and Accept Quotes | 2010-01-07 08:00 A → 2010-01-07 | 2010-01-07 14:00 A → 2010-01-07 | 5h → 3h | 100% → 0% | none → 0d | baseline start 2010-01-07 08:00 → none; baseline finish 2010-01-07 11:00 → none |
| 5 | Confirm Moving Day | 2010-01-11 08:00 A → 2010-01-07 (-4d) | 2010-01-11 10:00 A → 2010-01-07 (-4d) |  | 100% → 0% | none → 0d | constraint finish no later than 2010-01-08 17:00 → none; baseline start 2010-01-07 11:00 → none; baseline finish 2010-01-07 14:00 → none |
| 6 | **Fit Out New Premises** | 2010-01-11 10:00 A → 2010-01-07 (-4d) | 2010-01-20 15:00 A → 2010-01-19 (-1d) |  | 100% → 0% | none → 0d | baseline start 2010-01-07 14:00 → none; baseline finish 2010-01-19 09:00 → none |
| 7 | Power | 2010-01-11 10:00 A → 2010-01-07 (-4d) | 2010-01-11 15:00 A → 2010-01-08 (-3d) |  | 100% → 0% | none → 0d | baseline start 2010-01-07 14:00 → none; baseline finish 2010-01-08 09:00 → none |
| 8 | Cabling | 2010-01-11 15:00 A → 2010-01-08 (-3d) | 2010-01-15 15:00 A → 2010-01-14 (-1d) |  | 100% → 0% | none → 0d | baseline start 2010-01-08 09:00 → none; baseline finish 2010-01-14 09:00 → none |
| 9 | Decorating | 2010-01-13 15:00 A → 2010-01-12 (-1d) | 2010-01-20 15:00 A → 2010-01-19 (-1d) |  | 100% → 0% | none → 0d | baseline start 2010-01-12 09:00 → none; baseline finish 2010-01-19 09:00 → none |
| 10 | **Packing** | 2010-01-20 15:00 A → 2010-01-19 (-1d) | 2010-01-28 15:00 A → 2010-01-27 (-1d) |  | 100% → 0% | none → 0d | baseline start 2010-01-19 09:00 → none; baseline finish 2010-01-27 09:00 → none |
| 11 | Get Boxes | 2010-01-20 15:00 A → 2010-01-19 (-1d) | 2010-01-21 15:00 A → 2010-01-20 (-1d) |  | 100% → 0% | none → 0d | baseline start 2010-01-19 09:00 → none; baseline finish 2010-01-20 09:00 → none |
| 12 | Pack boxes | 2010-01-21 15:00 A → 2010-01-20 (-1d) | 2010-01-28 15:00 A → 2010-01-27 (-1d) |  | 100% → 0% | none → 0d | baseline start 2010-01-20 09:00 → none; baseline finish 2010-01-27 09:00 → none |
| 13 | Make Inventory | 2010-01-21 15:00 A → 2010-01-20 (-1d) | 2010-01-28 15:00 A → 2010-01-27 (-1d) |  | 100% → 0% | none → 0d | baseline start 2010-01-20 09:00 → none; baseline finish 2010-01-27 09:00 → none |
| 14 | Transport Boxes | 2010-01-28 15:00 A → 2010-01-27 (-1d) | 2010-01-29 15:00 → 2010-01-28 (-1d) | 1ed → 1d | 8% → 0% |  | baseline start 2010-01-27 09:00 → none; baseline finish 2010-01-28 09:00 → none |
| 15 | **Unpacking** | 2010-01-29 15:00 → 2010-01-28 (-1d) | 2010-02-05 15:00 → 2010-02-04 (-1d) |  |  |  | baseline start 2010-01-28 09:00 → none; baseline finish 2010-02-04 09:00 → none |
| 16 | Unpack Boxes | 2010-01-29 15:00 → 2010-01-28 (-1d) | 2010-02-05 15:00 → 2010-02-04 (-1d) |  |  |  | baseline start 2010-01-28 09:00 → none; baseline finish 2010-02-04 09:00 → none |
| 17 | Install Equipment | 2010-01-29 15:00 → 2010-01-28 (-1d) | 2010-02-05 15:00 → 2010-02-04 (-1d) |  |  |  | baseline start 2010-01-28 09:00 → none; baseline finish 2010-02-04 09:00 → none |
| 18 | Check Inventory | 2010-01-29 15:00 → 2010-01-28 (-1d) | 2010-02-05 15:00 → 2010-02-04 (-1d) |  |  |  | baseline start 2010-01-28 09:00 → none; baseline finish 2010-02-04 09:00 → none |
| 19 | Move In | 2010-02-05 15:00 → 2010-02-04 (-1d) | 2010-02-05 15:00 → 2010-02-04 (-1d) |  |  |  | baseline start 2010-02-04 09:00 → none; baseline finish 2010-02-04 09:00 → none |

## Version 3 (data date 2006-01-12, saved 2012-11-07, file CustomiseProjectPractice .mpp)

Last finish 2010-02-04 → 2010-02-01 (-3d).

Changed:

| ID | Task | Start | Finish | Duration | Predecessors | Other |
| --- | --- | --- | --- | --- | --- | --- |
| 1 | **Pre-work** |  |  | 3.62d → 3.5d |  | baseline start none → 2003-01-06; baseline finish none → 2003-01-09 |
| 2 | Get Fit-out quotes |  |  |  |  | resources none → Manager's PA; baseline start none → 2003-01-06; baseline finish none → 2003-01-07 |
| 3 | Get Moving Company Quotes |  |  |  | 2 → 2FS-5% | resources none → Manager's PA [50%]; baseline start none → 2003-01-08; baseline finish none → 2003-01-08 |
| 4 | Evaluate and Accept Quotes |  |  | 3h → 2h |  | resources none → Manager; baseline start none → 2003-01-09; baseline finish none → 2003-01-09 |
| 5 | Confirm Moving Day |  |  |  |  | resources none → Manager's PA; baseline start none → 2003-01-09; baseline finish none → 2003-01-09 |
| 6 | **Fit Out New Premises** |  | 2010-01-19 → 2010-01-15 (-4d) | 7.5d → 6.5d |  | baseline start none → 2003-01-09; baseline finish none → 2003-01-21 |
| 7 | Power |  | 2010-01-08 → 2010-01-07 (-1d) |  |  | resources none → Techies; baseline start none → 2003-01-09; baseline finish none → 2003-01-10 |
| 8 | Cabling |  | 2010-01-14 → 2010-01-11 (-3d) |  |  | resources none → Techies [300%]; baseline start none → 2003-01-10; baseline finish none → 2003-01-16 |
| 9 | Decorating | 2010-01-12 → 2010-01-11 (-1d) | 2010-01-19 → 2010-01-15 (-4d) |  | 8FS-5% → 8FS-1d | resources none → Decorators; baseline start none → 2003-01-14; baseline finish none → 2003-01-21 |
| 10 | **Packing** | 2010-01-19 → 2010-01-18 (-1d) | 2010-01-27 → 2010-01-24 (-3d) | 6d → 5d |  | baseline start none → 2003-01-21; baseline finish none → 2003-01-30 |
| 11 | Get Boxes | 2010-01-19 → 2010-01-18 (-1d) | 2010-01-20 → 2010-01-19 (-1d) | 1d → 2d |  | resources none → Boxes [20 Each]; Techies [200%]; baseline start none → 2003-01-21; baseline finish none → 2003-01-22 |
| 12 | Pack boxes |  | 2010-01-27 → 2010-01-24 (-3d) |  |  | resources none → Techies [300%]; baseline start none → 2003-01-22; baseline finish none → 2003-01-30 |
| 13 | Make Inventory |  | 2010-01-27 → 2010-01-24 (-3d) |  |  | resources none → Manager's PA; baseline start none → 2003-01-22; baseline finish none → 2003-01-30 |
| 14 | Transport Boxes | 2010-01-27 → 2010-01-25 (-2d) | 2010-01-28 → 2010-01-25 (-3d) |  |  | resources none → Moving Company; baseline start none → 2003-01-30; baseline finish none → 2003-01-31 |
| 15 | **Unpacking** | 2010-01-28 → 2010-01-26 (-2d) | 2010-02-04 → 2010-02-01 (-3d) |  |  | baseline start none → 2003-01-31; baseline finish none → 2003-02-10 |
| 16 | Unpack Boxes | 2010-01-28 → 2010-01-26 (-2d) | 2010-02-04 → 2010-02-01 (-3d) |  |  | resources none → Techies [150%]; baseline start none → 2003-01-31; baseline finish none → 2003-02-10 |
| 17 | Install Equipment | 2010-01-28 → 2010-01-26 (-2d) | 2010-02-04 → 2010-02-01 (-3d) |  |  | resources none → Techies [150%]; baseline start none → 2003-01-31; baseline finish none → 2003-02-10 |
| 18 | Check Inventory | 2010-01-28 → 2010-01-26 (-2d) | 2010-02-04 → 2010-02-01 (-3d) |  |  | resources none → Manager's PA; baseline start none → 2003-01-31; baseline finish none → 2003-02-10 |
| 19 | Move In | 2010-02-04 → 2010-02-01 (-3d) | 2010-02-04 → 2010-02-01 (-3d) |  |  | baseline start none → 2003-02-10; baseline finish none → 2003-02-10 |

## Version 4 (data date 2003-01-16, saved 2012-11-15, file AssortedTricksPractice.mpp)

Last finish 2010-02-01 → 2007-02-08 (-1089d).

Changed:

| ID | Task | Start | Finish | Duration | Total float | Predecessors | Other |
| --- | --- | --- | --- | --- | --- | --- | --- |
| 1 | **Pre-work** | 2010-01-04 → 2007-01-08 (-1092d) | 2010-01-07 → 2007-01-11 (-1092d) | 3.5d → 3.75d | 0d → 2.29d |  | baseline start 2003-01-06 → none; baseline finish 2003-01-09 → none |
| 2 | Get Fit-out quotes | 2010-01-04 → 2007-01-08 (-1092d) | 2010-01-05 → 2007-01-09 (-1092d) |  | 0d → 2.29d |  | baseline start 2003-01-06 → none; baseline finish 2003-01-07 → none |
| 3 | Get Moving Company Quotes | 2010-01-06 → 2007-01-10 (-1092d) | 2010-01-06 → 2007-01-10 (-1092d) |  | 0d → 2.29d |  | baseline start 2003-01-08 → none; baseline finish 2003-01-08 → none |
| 4 | Evaluate and Accept Quotes | 2010-01-07 → 2007-01-11 (-1092d) | 2010-01-07 → 2007-01-11 (-1092d) | 2h → 4h | 0d → 2.29d |  | baseline start 2003-01-09 → none; baseline finish 2003-01-09 → none |
| 5 | Confirm Moving Day | 2010-01-07 → 2007-01-11 (-1092d) | 2010-01-07 → 2007-01-11 (-1092d) |  | 0d → 2.29d |  | baseline start 2003-01-09 → none; baseline finish 2003-01-09 → none |
| 6 | **Fit Out New Premises** | 2010-01-07 → 2007-01-11 (-1092d) | 2010-01-15 → 2007-01-23 (-1088d) | 6.5d → 7.5d |  |  | baseline start 2003-01-09 → none; baseline finish 2003-01-21 → none |
| 7 | Power | 2010-01-07 → 2007-01-11 (-1092d) | 2010-01-07 → 2007-01-12 (-1091d) |  |  |  | baseline start 2003-01-09 → none; baseline finish 2003-01-10 → none |
| 8 | Cabling | 2010-01-08 → 2007-01-12 (-1092d) | 2010-01-11 → 2007-01-18 (-1089d) |  |  |  | resources Techies [300%] → Manager's PA [25%]; Techies [300%]; baseline start 2003-01-10 → none; baseline finish 2003-01-16 → none |
| 9 | Decorating | 2010-01-11 → 2007-01-16 (-1091d) | 2010-01-15 → 2007-01-23 (-1088d) |  |  | 8FS-1d → 8FS-5% | resources Decorators → Manager's PA [25%]; Decorators; baseline start 2003-01-14 → none; baseline finish 2003-01-21 → none |
| 10 | **Packing** | 2010-01-18 → 2007-01-23 (-1091d) | 2010-01-24 → 2007-01-31 (-1089d) | 5d → 6d |  |  | baseline start 2003-01-21 → none; baseline finish 2003-01-30 → none |
| 11 | Get Boxes | 2010-01-18 → 2007-01-23 (-1091d) | 2010-01-19 → 2007-01-24 (-1091d) | 2d → 1d |  |  | baseline start 2003-01-21 → none; baseline finish 2003-01-22 → none |
| 12 | Pack boxes | 2010-01-20 → 2007-01-24 (-1092d) | 2010-01-24 → 2007-01-31 (-1089d) |  |  |  | baseline start 2003-01-22 → none; baseline finish 2003-01-30 → none |
| 13 | Make Inventory | 2010-01-20 → 2007-01-24 (-1092d) | 2010-01-24 → 2007-01-31 (-1089d) |  |  |  | baseline start 2003-01-22 → none; baseline finish 2003-01-30 → none |
| 14 | Transport Boxes | 2010-01-25 → 2007-01-31 (-1090d) | 2010-01-25 → 2007-02-01 (-1089d) |  |  |  | baseline start 2003-01-30 → none; baseline finish 2003-01-31 → none |
| 15 | **Unpacking** | 2010-01-26 → 2007-02-01 (-1090d) | 2010-02-01 → 2007-02-08 (-1089d) |  |  |  | baseline start 2003-01-31 → none; baseline finish 2003-02-10 → none |
| 16 | Unpack Boxes | 2010-01-26 → 2007-02-01 (-1090d) | 2010-02-01 → 2007-02-08 (-1089d) |  |  |  | baseline start 2003-01-31 → none; baseline finish 2003-02-10 → none |
| 17 | Install Equipment | 2010-01-26 → 2007-02-01 (-1090d) | 2010-02-01 → 2007-02-08 (-1089d) |  |  |  | baseline start 2003-01-31 → none; baseline finish 2003-02-10 → none |
| 18 | Check Inventory | 2010-01-26 → 2007-02-01 (-1090d) | 2010-02-01 → 2007-02-08 (-1089d) |  |  |  | baseline start 2003-01-31 → none; baseline finish 2003-02-10 → none |
| 19 | Move In | 2010-02-01 → 2007-02-08 (-1089d) | 2010-02-01 → 2007-02-08 (-1089d) |  |  |  | baseline start 2003-02-10 → none; baseline finish 2003-02-10 → none |

## Version 5 (saved 2013-08-08, file MoveOfficeTasks.mpp)

Last finish 2007-02-08 → 2013-01-11 (+2164d).

Added:

| ID | Task | Duration | Start | Finish |
| --- | --- | --- | --- | --- |
| 1 | Pre-work | 1d | 2013-01-07 | 2013-01-07 |
| 6 | Fit Out New Premises | 1d | 2013-01-07 | 2013-01-07 |
| 10 | Packing | 1d | 2013-01-07 | 2013-01-07 |
| 15 | Unpacking | 1d | 2013-01-07 | 2013-01-07 |

Removed: 1 Pre-work; 6 Fit Out New Premises; 10 Packing; 15 Unpacking; 16 Unpack Boxes; 17 Install Equipment; 18 Check Inventory; 19 Move In

Changed:

| ID | Task | Start | Finish | Duration | Total float | Predecessors | Other |
| --- | --- | --- | --- | --- | --- | --- | --- |
| 2 | Get Fit-out quotes | 2007-01-08 → 2013-01-07 (+2191d) | 2007-01-09 → 2013-01-08 (+2191d) |  | 2.29d → none |  | resources Manager's PA → none |
| 3 | Get Moving Company Quotes | 2007-01-10 → 2013-01-07 (+2189d) | 2007-01-10 → 2013-01-07 (+2189d) |  | 2.29d → none | 2FS-5% → none | resources Manager's PA [50%] → none |
| 4 | Evaluate and Accept Quotes | 2007-01-11 → 2013-01-07 (+2188d) | 2007-01-11 → 2013-01-07 (+2188d) | 4h → 3h | 2.29d → none | 3 → none | resources Manager → none |
| 5 | Confirm Moving Day | 2007-01-11 → 2013-01-07 (+2188d) | 2007-01-11 → 2013-01-07 (+2188d) |  | 2.29d → none | 4 → none | resources Manager's PA → none |
| 7 | Power | 2007-01-11 → 2013-01-07 (+2188d) | 2007-01-12 → 2013-01-07 (+2187d) |  | 0d → none |  | resources Techies → none |
| 8 | Cabling | 2007-01-12 → 2013-01-07 (+2187d) | 2007-01-18 → 2013-01-10 (+2184d) |  | 0d → none | 7 → none | resources Manager's PA [25%]; Techies [300%] → none |
| 9 | Decorating | 2007-01-16 → 2013-01-07 (+2183d) | 2007-01-23 → 2013-01-11 (+2180d) |  | 0d → none | 8FS-5% → none | resources Manager's PA [25%]; Decorators → none |
| 11 | Get Boxes | 2007-01-23 → 2013-01-07 (+2176d) | 2007-01-24 → 2013-01-07 (+2175d) |  | 0d → none |  | resources Boxes [20 Each]; Techies [200%] → none |
| 12 | Pack boxes | 2007-01-24 → 2013-01-07 (+2175d) | 2007-01-31 → 2013-01-11 (+2172d) |  | 0d → none | 11 → none | resources Techies [300%] → none |
| 13 | Make Inventory | 2007-01-24 → 2013-01-07 (+2175d) | 2007-01-31 → 2013-01-11 (+2172d) |  | 0d → none | 12SS → none | resources Manager's PA → none |
| 14 | Transport Boxes | 2007-01-31 → 2013-01-07 (+2168d) | 2007-02-01 → 2013-01-08 (+2168d) | 1d → 1ed | 0d → none | Packing → none | resources Moving Company → none |

## Version 6 (saved 2013-08-08, file MoveOfficeRelationships.mpp)

Last finish stays 2013-01-11.

Added:

| ID | Task | Duration | Start | Finish |
| --- | --- | --- | --- | --- |
| 16 | Unpack Boxes | 1w | 2013-01-07 | 2013-01-11 |
| 17 | Install Equipment | 1w | 2013-01-07 | 2013-01-11 |
| 18 | Check Inventory | 1w | 2013-01-07 | 2013-01-11 |
| 19 | Move In | 0d | 2013-01-07 | 2013-01-07 |

## Version 7 (saved 2013-08-09, file MoveOfficeTracking.mpp)

Last finish 2013-01-11 → 2013-02-21 (+41d).

Changed:

| ID | Task | Start | Finish | Duration | Total float | Predecessors | Other |
| --- | --- | --- | --- | --- | --- | --- | --- |
| 1 | **Pre-work** |  | 2013-01-07 → 2013-01-10 (+3d) | 1d → 3.62d | none → 0d |  |  |
| 3 | Get Moving Company Quotes | 2013-01-07 → 2013-01-09 (+2d) | 2013-01-07 → 2013-01-09 (+2d) |  | none → 0d | none → 2 |  |
| 4 | Evaluate and Accept Quotes | 2013-01-07 → 2013-01-10 (+3d) | 2013-01-07 → 2013-01-10 (+3d) |  | none → 0d | none → 3 |  |
| 5 | Confirm Moving Day | 2013-01-07 → 2013-01-10 (+3d) | 2013-01-07 → 2013-01-10 (+3d) |  | none → 0d | none → 4 | constraint none → finish no later than 2013-01-11 |
| 6 | **Fit Out New Premises** | 2013-01-07 → 2013-01-10 (+3d) | 2013-01-07 → 2013-01-22 (+15d) | 1d → 7.5d | none → 0d | none → 1 |  |
| 7 | Power | 2013-01-07 → 2013-01-10 (+3d) | 2013-01-07 → 2013-01-11 (+4d) |  | none → 0d |  |  |
| 8 | Cabling | 2013-01-07 → 2013-01-11 (+4d) | 2013-01-10 → 2013-01-17 (+7d) |  | none → 0d | none → 7 |  |
| 9 | Decorating | 2013-01-07 → 2013-01-15 (+8d) | 2013-01-11 → 2013-01-22 (+11d) |  | none → 0d | none → 8FS-5% |  |
| 10 | **Packing** | 2013-01-07 → 2013-01-22 (+15d) | 2013-01-07 → 2013-01-30 (+23d) | 1d → 6d | none → 0d | none → 6 |  |
| 11 | Get Boxes | 2013-01-07 → 2013-01-22 (+15d) | 2013-01-07 → 2013-01-23 (+16d) |  | none → 0d |  |  |
| 12 | Pack boxes | 2013-01-07 → 2013-01-23 (+16d) | 2013-01-11 → 2013-01-30 (+19d) |  | none → 0d | none → 11 |  |
| 13 | Make Inventory | 2013-01-07 → 2013-01-23 (+16d) | 2013-01-11 → 2013-01-30 (+19d) |  | none → 0d | none → 12SS |  |
| 14 | Transport Boxes | 2013-01-07 → 2013-01-30 (+23d) | 2013-01-08 → 2013-01-31 (+23d) |  | none → 0d | none → 10 |  |
| 15 | **Unpacking** | 2013-01-07 → 2013-01-31 (+24d) | 2013-01-07 → 2013-02-21 (+45d) | 1d → 15d | none → 0d | none → 14 |  |
| 16 | Unpack Boxes | 2013-01-07 → 2013-01-31 (+24d) | 2013-01-11 → 2013-02-07 (+27d) |  | none → 0d |  |  |
| 17 | Install Equipment | 2013-01-07 → 2013-02-07 (+31d) | 2013-01-11 → 2013-02-14 (+34d) |  | none → 0d | none → 16 |  |
| 18 | Check Inventory | 2013-01-07 → 2013-02-14 (+38d) | 2013-01-11 → 2013-02-21 (+41d) |  | none → 0d | none → 17 |  |
| 19 | Move In | 2013-01-07 → 2013-02-21 (+45d) | 2013-01-07 → 2013-02-21 (+45d) |  | none → 0d | none → 15 |  |

## Version 8 (data date 2013-01-31, saved 2013-08-09, file MoveOfficeReporting.mpp)

Last finish 2013-02-21 → 2013-02-22 (+1d). Complete tasks 0 → 10.

Changed:

| ID | Task | Start | Finish | Duration | Complete | Total float | Other |
| --- | --- | --- | --- | --- | --- | --- | --- |
| 1 | **Pre-work** | 2013-01-07 A | 2013-01-10 → 2013-01-14 A (+4d) | 3.62d → 5.25d | 0% → 100% | 0d → none | baseline start none → 2013-01-07; baseline finish none → 2013-01-10 |
| 2 | Get Fit-out quotes | 2013-01-07 A | 2013-01-08 A |  | 0% → 100% | 0d → none | baseline start none → 2013-01-07; baseline finish none → 2013-01-08 |
| 3 | Get Moving Company Quotes | 2013-01-09 A | 2013-01-09 A |  | 0% → 100% | 0d → none | baseline start none → 2013-01-09; baseline finish none → 2013-01-09 |
| 4 | Evaluate and Accept Quotes | 2013-01-10 A | 2013-01-10 A | 3h → 5h | 0% → 100% | 0d → none | baseline start none → 2013-01-10; baseline finish none → 2013-01-10 |
| 5 | Confirm Moving Day | 2013-01-10 → 2013-01-14 A (+4d) | 2013-01-10 → 2013-01-14 A (+4d) |  | 0% → 100% | 0d → none | baseline start none → 2013-01-10; baseline finish none → 2013-01-10 |
| 6 | **Fit Out New Premises** | 2013-01-10 → 2013-01-14 A (+4d) | 2013-01-22 → 2013-01-23 A (+1d) |  | 0% → 100% | 0d → none | baseline start none → 2013-01-10; baseline finish none → 2013-01-22 |
| 7 | Power | 2013-01-10 → 2013-01-14 A (+4d) | 2013-01-11 → 2013-01-14 A (+3d) |  | 0% → 100% | 0d → none | baseline start none → 2013-01-10; baseline finish none → 2013-01-11 |
| 8 | Cabling | 2013-01-11 → 2013-01-14 A (+3d) | 2013-01-17 → 2013-01-18 A (+1d) |  | 0% → 100% | 0d → none | baseline start none → 2013-01-11; baseline finish none → 2013-01-17 |
| 9 | Decorating | 2013-01-15 → 2013-01-16 A (+1d) | 2013-01-22 → 2013-01-23 A (+1d) |  | 0% → 100% | 0d → none | baseline start none → 2013-01-15; baseline finish none → 2013-01-22 |
| 10 | **Packing** | 2013-01-22 → 2013-01-23 A (+1d) | 2013-01-30 → 2013-01-31 A (+1d) |  | 0% → 100% | 0d → none | baseline start none → 2013-01-22; baseline finish none → 2013-01-30 |
| 11 | Get Boxes | 2013-01-22 → 2013-01-23 A (+1d) | 2013-01-23 → 2013-01-24 A (+1d) |  | 0% → 100% | 0d → none | baseline start none → 2013-01-22; baseline finish none → 2013-01-23 |
| 12 | Pack boxes | 2013-01-23 → 2013-01-24 A (+1d) | 2013-01-30 → 2013-01-31 A (+1d) |  | 0% → 100% | 0d → none | baseline start none → 2013-01-23; baseline finish none → 2013-01-30 |
| 13 | Make Inventory | 2013-01-23 → 2013-01-24 A (+1d) | 2013-01-30 → 2013-01-31 A (+1d) |  | 0% → 100% | 0d → none | baseline start none → 2013-01-23; baseline finish none → 2013-01-30 |
| 14 | Transport Boxes | 2013-01-30 → 2013-01-31 A (+1d) | 2013-01-31 → 2013-02-01 (+1d) |  | 0% → 8% |  | baseline start none → 2013-01-30; baseline finish none → 2013-01-31 |
| 15 | **Unpacking** | 2013-01-31 → 2013-02-01 (+1d) | 2013-02-21 → 2013-02-22 (+1d) |  |  |  | baseline start none → 2013-01-31; baseline finish none → 2013-02-21 |
| 16 | Unpack Boxes | 2013-01-31 → 2013-02-01 (+1d) | 2013-02-07 → 2013-02-08 (+1d) |  |  |  | baseline start none → 2013-01-31; baseline finish none → 2013-02-07 |
| 17 | Install Equipment | 2013-02-07 → 2013-02-08 (+1d) | 2013-02-14 → 2013-02-15 (+1d) |  |  |  | baseline start none → 2013-02-07; baseline finish none → 2013-02-14 |
| 18 | Check Inventory | 2013-02-14 → 2013-02-15 (+1d) | 2013-02-21 → 2013-02-22 (+1d) |  |  |  | baseline start none → 2013-02-14; baseline finish none → 2013-02-21 |
| 19 | Move In | 2013-02-21 → 2013-02-22 (+1d) | 2013-02-21 → 2013-02-22 (+1d) |  |  |  | baseline start none → 2013-02-21; baseline finish none → 2013-02-21 |

## Version 9 (data date 2010-01-28, saved 2013-08-13, file CreateResourcesPractice.mpp)

Last finish 2013-02-22 → 2013-02-07 (-15d). Complete tasks 10 → 0.

Changed:

| ID | Task | Start | Finish | Duration | Complete | Total float | Predecessors | Other |
| --- | --- | --- | --- | --- | --- | --- | --- | --- |
| 1 | **Pre-work** | 2013-01-07 A → 2013-01-07 | 2013-01-14 A → 2013-01-10 (-4d) | 5.25d → 3.62d | 100% → 0% | none → 0d |  | baseline start 2013-01-07 → none; baseline finish 2013-01-10 → none |
| 2 | Get Fit-out quotes | 2013-01-07 A → 2013-01-07 | 2013-01-08 A → 2013-01-08 |  | 100% → 0% | none → 0d |  | baseline start 2013-01-07 → none; baseline finish 2013-01-08 → none |
| 3 | Get Moving Company Quotes | 2013-01-09 A → 2013-01-09 | 2013-01-09 A → 2013-01-09 |  | 100% → 0% | none → 0d |  | baseline start 2013-01-09 → none; baseline finish 2013-01-09 → none |
| 4 | Evaluate and Accept Quotes | 2013-01-10 A → 2013-01-10 | 2013-01-10 A → 2013-01-10 | 5h → 3h | 100% → 0% | none → 0d |  | baseline start 2013-01-10 → none; baseline finish 2013-01-10 → none |
| 5 | Confirm Moving Day | 2013-01-14 A → 2013-01-10 (-4d) | 2013-01-14 A → 2013-01-10 (-4d) |  | 100% → 0% | none → 0d |  | baseline start 2013-01-10 → none; baseline finish 2013-01-10 → none |
| 6 | **Fit Out New Premises** | 2013-01-14 A → 2013-01-10 (-4d) | 2013-01-23 A → 2013-01-22 (-1d) |  | 100% → 0% | none → 0d |  | baseline start 2013-01-10 → none; baseline finish 2013-01-22 → none |
| 7 | Power | 2013-01-14 A → 2013-01-10 (-4d) | 2013-01-14 A → 2013-01-11 (-3d) |  | 100% → 0% | none → 0d |  | baseline start 2013-01-10 → none; baseline finish 2013-01-11 → none |
| 8 | Cabling | 2013-01-14 A → 2013-01-11 (-3d) | 2013-01-18 A → 2013-01-17 (-1d) |  | 100% → 0% | none → 0d |  | baseline start 2013-01-11 → none; baseline finish 2013-01-17 → none |
| 9 | Decorating | 2013-01-16 A → 2013-01-15 (-1d) | 2013-01-23 A → 2013-01-22 (-1d) |  | 100% → 0% | none → 0d |  | baseline start 2013-01-15 → none; baseline finish 2013-01-22 → none |
| 10 | **Packing** | 2013-01-23 A → 2013-01-22 (-1d) | 2013-01-31 A → 2013-01-30 (-1d) |  | 100% → 0% | none → 0d |  | baseline start 2013-01-22 → none; baseline finish 2013-01-30 → none |
| 11 | Get Boxes | 2013-01-23 A → 2013-01-22 (-1d) | 2013-01-24 A → 2013-01-23 (-1d) |  | 100% → 0% | none → 0d |  | baseline start 2013-01-22 → none; baseline finish 2013-01-23 → none |
| 12 | Pack boxes | 2013-01-24 A → 2013-01-23 (-1d) | 2013-01-31 A → 2013-01-30 (-1d) |  | 100% → 0% | none → 0d |  | baseline start 2013-01-23 → none; baseline finish 2013-01-30 → none |
| 13 | Make Inventory | 2013-01-24 A → 2013-01-23 (-1d) | 2013-01-31 A → 2013-01-30 (-1d) |  | 100% → 0% | none → 0d |  | baseline start 2013-01-23 → none; baseline finish 2013-01-30 → none |
| 14 | Transport Boxes | 2013-01-31 A → 2013-01-30 (-1d) | 2013-02-01 → 2013-01-31 (-1d) |  | 8% → 0% |  |  | baseline start 2013-01-30 → none; baseline finish 2013-01-31 → none |
| 15 | **Unpacking** | 2013-02-01 → 2013-01-31 (-1d) | 2013-02-22 → 2013-02-07 (-15d) | 15d → 5d |  |  |  | baseline start 2013-01-31 → none; baseline finish 2013-02-21 → none |
| 16 | Unpack Boxes | 2013-02-01 → 2013-01-31 (-1d) | 2013-02-08 → 2013-02-07 (-1d) |  |  |  |  | baseline start 2013-01-31 → none; baseline finish 2013-02-07 → none |
| 17 | Install Equipment | 2013-02-08 → 2013-01-31 (-8d) | 2013-02-15 → 2013-02-07 (-8d) |  |  |  | 16 → 16FF | baseline start 2013-02-07 → none; baseline finish 2013-02-14 → none |
| 18 | Check Inventory | 2013-02-15 → 2013-01-31 (-15d) | 2013-02-22 → 2013-02-07 (-15d) |  |  |  | 17 → 17FF | baseline start 2013-02-14 → none; baseline finish 2013-02-21 → none |
| 19 | Move In | 2013-02-22 → 2013-02-07 (-15d) | 2013-02-22 → 2013-02-07 (-15d) |  |  |  |  | baseline start 2013-02-21 → none; baseline finish 2013-02-21 → none |

## Version 10 (data date 2010-01-28, saved 2013-08-19, file OverallocationsPractice.mpp)

Last finish 2013-02-07 → 2013-02-05 (-2d).

Changed:

| ID | Task | Start | Finish | Duration | Total float | Predecessors | Other |
| --- | --- | --- | --- | --- | --- | --- | --- |
| 1 | **Pre-work** |  | 2013-01-10 → 2013-01-09 (-1d) | 3.62d → 2.44d |  |  |  |
| 2 | Get Fit-out quotes |  |  | 2d → 1.82d |  |  | resources none → Manager’s PA [110%] |
| 3 | Get Moving Company Quotes | 2013-01-09 → 2013-01-07 (-2d) | 2013-01-09 → 2013-01-08 (-1d) |  |  | 2 → 2FS-1d | resources none → Manager’s PA [50%] |
| 4 | Evaluate and Accept Quotes | 2013-01-10 → 2013-01-08 (-2d) | 2013-01-10 → 2013-01-09 (-1d) |  |  |  | resources none → Manager |
| 5 | Confirm Moving Day | 2013-01-10 → 2013-01-09 (-1d) | 2013-01-10 → 2013-01-09 (-1d) |  |  |  | resources none → Manager’s PA |
| 6 | **Fit Out New Premises** | 2013-01-10 → 2013-01-09 (-1d) | 2013-01-22 → 2013-01-18 (-4d) |  |  |  |  |
| 7 | Power | 2013-01-10 → 2013-01-09 (-1d) | 2013-01-11 → 2013-01-09 (-2d) |  |  |  | resources none → Techies |
| 8 | Cabling | 2013-01-11 → 2013-01-09 (-2d) | 2013-01-17 → 2013-01-15 (-2d) |  |  |  | resources none → Manager’s PA [25%]; Techies [300%] |
| 9 | Decorating | 2013-01-15 → 2013-01-11 (-4d) | 2013-01-22 → 2013-01-18 (-4d) |  |  |  | resources none → Manager’s PA [25%]; Techies |
| 10 | **Packing** | 2013-01-22 → 2013-01-18 (-4d) | 2013-01-30 → 2013-01-28 (-2d) |  |  |  |  |
| 11 | Get Boxes | 2013-01-22 → 2013-01-18 (-4d) | 2013-01-23 → 2013-01-21 (-2d) |  |  |  | resources none → Boxes [20 Each]; Techies [200%] |
| 12 | Pack boxes | 2013-01-23 → 2013-01-21 (-2d) | 2013-01-30 → 2013-01-28 (-2d) |  |  |  | resources none → Techies [300%] |
| 13 | Make Inventory | 2013-01-23 → 2013-01-21 (-2d) | 2013-01-30 → 2013-01-28 (-2d) |  |  |  | resources none → Manager’s PA |
| 14 | Transport Boxes | 2013-01-30 → 2013-01-28 (-2d) | 2013-01-31 → 2013-01-29 (-2d) | 1ed → 1d |  |  | resources none → Moving Company |
| 15 | **Unpacking** | 2013-01-31 → 2013-01-29 (-2d) | 2013-02-07 → 2013-02-05 (-2d) |  |  |  |  |
| 16 | Unpack Boxes | 2013-01-31 → 2013-01-29 (-2d) | 2013-02-07 → 2013-02-04 (-3d) | 1w → 0.75w | 0d → 1.25d |  | resources none → Techies [200%] |
| 17 | Install Equipment | 2013-01-31 → 2013-01-29 (-2d) | 2013-02-07 → 2013-02-04 (-3d) | 1w → 0.75w | 0d → 1.25d |  | resources none → Techies [200%] |
| 18 | Check Inventory | 2013-01-31 → 2013-01-29 (-2d) | 2013-02-07 → 2013-02-05 (-2d) |  |  |  | resources none → Manager’s PA |
| 19 | Move In | 2013-02-07 → 2013-02-05 (-2d) | 2013-02-07 → 2013-02-05 (-2d) |  |  |  |  |

## Version 11 (data date 2010-01-28, saved 2013-08-19, file ResourceCostsPractice.mpp)

Last finish 2013-02-05 → 2013-02-07 (+2d).

Changed:

| ID | Task | Start | Finish | Duration | Total float | Predecessors | Other |
| --- | --- | --- | --- | --- | --- | --- | --- |
| 1 | **Pre-work** |  | 2013-01-09 → 2013-01-10 (+1d) | 2.44d → 3.62d |  |  |  |
| 2 | Get Fit-out quotes |  |  | 1.82d → 2d |  |  | resources Manager’s PA [110%] → Manager’s PA |
| 3 | Get Moving Company Quotes | 2013-01-07 → 2013-01-09 (+2d) | 2013-01-08 → 2013-01-09 (+1d) |  |  | 2FS-1d → 2 |  |
| 4 | Evaluate and Accept Quotes | 2013-01-08 → 2013-01-10 (+2d) | 2013-01-09 → 2013-01-10 (+1d) |  |  |  |  |
| 5 | Confirm Moving Day | 2013-01-09 → 2013-01-10 (+1d) | 2013-01-09 → 2013-01-10 (+1d) |  |  |  |  |
| 6 | **Fit Out New Premises** | 2013-01-09 → 2013-01-10 (+1d) | 2013-01-18 → 2013-01-22 (+4d) |  |  |  |  |
| 7 | Power | 2013-01-09 → 2013-01-10 (+1d) | 2013-01-09 → 2013-01-11 (+2d) |  |  |  |  |
| 8 | Cabling | 2013-01-09 → 2013-01-11 (+2d) | 2013-01-15 → 2013-01-17 (+2d) |  |  |  |  |
| 9 | Decorating | 2013-01-11 → 2013-01-15 (+4d) | 2013-01-18 → 2013-01-22 (+4d) |  |  |  | resources Manager’s PA [25%]; Techies → Manager’s PA [25%]; Decorators |
| 10 | **Packing** | 2013-01-18 → 2013-01-22 (+4d) | 2013-01-28 → 2013-01-30 (+2d) |  |  |  |  |
| 11 | Get Boxes | 2013-01-18 → 2013-01-22 (+4d) | 2013-01-21 → 2013-01-23 (+2d) |  |  |  |  |
| 12 | Pack boxes | 2013-01-21 → 2013-01-23 (+2d) | 2013-01-28 → 2013-01-30 (+2d) |  |  |  |  |
| 13 | Make Inventory | 2013-01-21 → 2013-01-23 (+2d) | 2013-01-28 → 2013-01-30 (+2d) |  |  |  |  |
| 14 | Transport Boxes | 2013-01-28 → 2013-01-30 (+2d) | 2013-01-29 → 2013-01-31 (+2d) |  |  |  |  |
| 15 | **Unpacking** | 2013-01-29 → 2013-01-31 (+2d) | 2013-02-05 → 2013-02-07 (+2d) |  |  |  |  |
| 16 | Unpack Boxes | 2013-01-29 → 2013-01-31 (+2d) | 2013-02-04 → 2013-02-07 (+3d) | 0.75w → 1w | 1.25d → 0d |  | resources Techies [200%] → Techies [150%] |
| 17 | Install Equipment | 2013-01-29 → 2013-01-31 (+2d) | 2013-02-04 → 2013-02-07 (+3d) | 0.75w → 1w | 1.25d → 0d |  | resources Techies [200%] → Techies [150%] |
| 18 | Check Inventory | 2013-01-29 → 2013-01-31 (+2d) | 2013-02-05 → 2013-02-07 (+2d) |  |  |  |  |
| 19 | Move In | 2013-02-05 → 2013-02-07 (+2d) | 2013-02-05 → 2013-02-07 (+2d) |  |  |  |  |

## Version 12 (data date 2010-01-28, saved 2013-08-19, file ReportResourcesPractice.mpp)

Last finish stays 2013-02-07. Complete tasks 0 → 6.

Changed:

| ID | Task | Start | Finish | Complete | Total float | Other |
| --- | --- | --- | --- | --- | --- | --- |
| 1 | **Pre-work** | 2013-01-07 A | 2013-01-10 A | 0% → 100% | 0d → none | baseline start none → 2010-01-04; baseline finish none → 2010-01-07 |
| 2 | Get Fit-out quotes | 2013-01-07 A | 2013-01-08 A | 0% → 100% | 0d → none | baseline start none → 2010-01-04; baseline finish none → 2010-01-05 |
| 3 | Get Moving Company Quotes | 2013-01-09 A | 2013-01-09 A | 0% → 100% | 0d → none | baseline start none → 2010-01-06; baseline finish none → 2010-01-06 |
| 4 | Evaluate and Accept Quotes | 2013-01-10 A | 2013-01-10 A | 0% → 100% | 0d → none | baseline start none → 2010-01-07; baseline finish none → 2010-01-07 |
| 5 | Confirm Moving Day | 2013-01-10 A | 2013-01-10 A | 0% → 100% | 0d → none | constraint finish no later than 2013-01-11 → none; baseline start none → 2010-01-07; baseline finish none → 2010-01-07 |
| 6 | **Fit Out New Premises** | 2013-01-10 A |  | 0% → 74% |  | baseline start none → 2010-01-07; baseline finish none → 2010-01-19 |
| 7 | Power | 2013-01-10 A | 2013-01-11 A | 0% → 100% | 0d → none | baseline start none → 2010-01-07; baseline finish none → 2010-01-08 |
| 8 | Cabling | 2013-01-11 A | 2013-01-17 A | 0% → 100% | 0d → none | baseline start none → 2010-01-08; baseline finish none → 2010-01-14 |
| 9 | Decorating | 2013-01-15 A |  | 0% → 50% |  | baseline start none → 2010-01-12; baseline finish none → 2010-01-19 |
| 10 | **Packing** |  |  |  |  | baseline start none → 2010-01-19; baseline finish none → 2010-01-27 |
| 11 | Get Boxes |  |  |  |  | baseline start none → 2010-01-19; baseline finish none → 2010-01-20 |
| 12 | Pack boxes |  |  |  |  | baseline start none → 2010-01-20; baseline finish none → 2010-01-27 |
| 13 | Make Inventory |  |  |  |  | baseline start none → 2010-01-20; baseline finish none → 2010-01-27 |
| 14 | Transport Boxes |  |  |  |  | baseline start none → 2010-01-27; baseline finish none → 2010-01-28 |
| 15 | **Unpacking** |  |  |  |  | baseline start none → 2010-01-28; baseline finish none → 2010-02-04 |
| 16 | Unpack Boxes |  |  |  |  | baseline start none → 2010-01-28; baseline finish none → 2010-02-04 |
| 17 | Install Equipment |  |  |  |  | baseline start none → 2010-01-28; baseline finish none → 2010-02-04 |
| 18 | Check Inventory |  |  |  |  | baseline start none → 2010-01-28; baseline finish none → 2010-02-04 |
| 19 | Move In |  |  |  |  | baseline start none → 2010-02-04; baseline finish none → 2010-02-04 |
